# 1059 Gannt 2025_11_24

Schedule from GanttProject, 2025-11-24 to 2026-09-29.

## Calendars

- Project calendar: Mon-Fri working; Sat-Sun off. Exceptions (off unless hours are given): 2025-12-22 to 2026-01-05, 2026-04-09 to 2026-04-13.

## Resources

| Resource |
| --- |
| Αργύρης Οικονόμου, Gas Klima (Τοποθετητής Θανάσης Δεληγιάννης) |
| Πέτρος Κλωνής, Develime Δεβετζόγλου |
| Θανάσης Φωκάς |

## Schedule

| ID | WBS | Task | Type | Duration | Start | Finish | Predecessors | Complete | Resources | Greek Name |
| --- | --- | --- | --- | --- | --- | --- | --- | --- | --- | --- |
| 1 | 1 | **Completed** |  | 102d | 2025-11-24 | 2026-05-04 |  | 100% |  |  |
| 2 | 1.1 | Columns & beams exterior insulation |  | 8d | 2025-11-24 | 2025-12-03 |  | 100% |  | Θερμομόνωση μπετόν |
| 3 | 1.2 | Final MEP design | milestone | 0d | 2025-12-09 | 2025-12-09 |  |  |  | Ολοκλήρωση μελετών Η-Μ |
| 4 | 1.3 | Ceiling electrical infrastructure |  | 9d | 2025-11-28 | 2025-12-10 |  | 100% |  | Καλωδιώσεις οροφών, σοβά |
| 5 | 1.4 | Ceiling plastering |  | 11d | 2025-11-28 | 2025-12-12 |  | 100% | Θανάσης Φωκάς | Σοβάδες ταβάνια |
| 6 | 1.5 | Drywall & ceiling instal.-1st stage |  | 7d | 2025-12-15 | 2026-01-07 | 4, 5 | 100% |  | Γυψοσανίδες 1η φάση |
| 7 | 1.6 | Window measurement | milestone | 0d | 2026-01-08 | 2026-01-08 | 6 | 100% |  | Μετρήσεις κουφωμάτων |
| 8 | 1.7 | Sanitary fixtures decision | milestone | 0d | 2026-01-26 | 2026-01-26 |  | 100% |  | Επιλογές εντοιχ.ειδών υγιεινής |
| 9 | 1.8 | Deliveryin-wall parts | milestone | 0d | 2026-03-02 | 2026-03-02 |  | 100% |  | Επιλογές εντοιχ.ειδών υγιεινής |
| 10 | 1.9 | In wall/floor plumbing piping |  | 28d | 2026-01-29 | 2026-03-09 | 6SS+3d, 8FS-5d, 9FF+6d | 100% |  | Υδραυλικές σωληνώσεις δαπέδων κ τοίχων |
| 11 | 1.10 | Delivery in-floor light housing | milestone | 0d | 2026-03-05 | 2026-03-05 |  |  |  | Παράδοση κουτιά εγκυβωτισμού, φώτα δαπέδου |
| 12 | 1.11 | In-wall/floor electrical conduits |  | 28d | 2026-01-29 | 2026-03-09 | 6SS+14d, 11FF+3d | 100% |  | Καλωδιώσεις δαπέδων κ τοίχων |
| 13 | 1.12 | Drywalls installation 2nd phase |  | 8d | 2026-03-10 | 2026-03-19 | 10, 12 | 100% |  | Γυψοσανίδες 2η φάση |
| 14 | 1.13 | A/C piping |  | 1d | 2026-03-04 | 2026-03-04 |  | 100% |  |  |
| 15 | 1.14 | Floor insulation |  | 2d | 2026-04-06 | 2026-04-07 | 10, 12, 13 | 100% | Αργύρης Οικονόμου, Gas Klima (Τοποθετητής Θανάσης Δεληγιάννης) | Θερμομονωτικά δαπέδων |
| 16 | 1.15 | Infloor elec. heating installation |  | 4d | 2026-04-08 | 2026-04-16 | 3, 6, 15 | 100% | Αργύρης Οικονόμου, Gas Klima (Τοποθετητής Θανάσης Δεληγιάννης) | Ενδοδαπέδια ηλεκτρική |
| 17 | 1.16 | Concrete floor indoor installation |  | 12d | 2026-04-17 | 2026-05-04 | 16 | 100% | Πέτρος Κλωνής, Develime Δεβετζόγλου | "Μωσαϊκό" δάπεδο |
| 18 | 1.17 | Windows sills installation |  | 2d | 2026-03-20 | 2026-03-23 |  | 100% | Θανάσης Φωκάς | Ποδιές παραθύρων |
| 19 | 2 | A/C infrastructure |  | 5d | 2026-05-05 | 2026-05-11 | 17 | 100% |  |  |
| 20 | 3 | **Building tasks** |  | 93d | 2026-05-08 | 2026-09-15 |  | 1% |  |  |
| 21 | 3.1 | Floor fill guesthouse |  | 2d | 2026-05-15 | 2026-05-18 | 10, 12 | 100% |  | Δάπεδο ξενώνα, γέμισμα κ εξομάλυνση |
| 22 | 3.2 | Basement screed floor |  | 3d | 2026-05-08 | 2026-05-12 | 16 |  |  | Δάπεδο υπογείου, γέμισμα κ εξομάλυνση |
| 23 | 3.3 | Basement and guesthouse tiling |  | 4d | 2026-05-19 | 2026-05-22 | 21, 22 |  |  | Επίστρωση πλακιδίων, υπόγειο κ ξενώνας |
| 24 | 3.4 | Interior stone cladding |  | 12d | 2026-05-08 | 2026-05-25 | 17 |  |  | Επένδυση λιθοδομή |
| 25 | 3.5 | Finish drywalls of Art Studio | milestone | 0d | 2026-05-25 | 2026-05-25 |  |  |  | Εργασίες σε στούντιο |
| 26 | 3.6 | Dropped ceiling boarding, wall finishes |  | 3d | 2026-05-25 | 2026-05-27 | 19, 25 |  |  | Κλείσιμο ψευδοροφών, γωνιόκρ.τοίχων |
| 27 | 3.7 | Base of wash basins |  | 6d | 2026-05-22 | 2026-05-29 |  |  |  |  |
| 28 | 3.8 | Microcement bath walls -1 |  | 10d | 2026-06-01 | 2026-06-12 | 27 |  |  |  |
| 29 | 3.9 | Concrete floor indoor buffing |  | 6d | 2026-06-15 | 2026-06-22 |  |  | Πέτρος Κλωνής, Develime Δεβετζόγλου | "Μωσαϊκό" δάπεδο |
| 30 | 3.10 | Microcement bath walls -2 |  | 10d | 2026-06-23 | 2026-07-06 | 26, 28, 29 |  |  |  |
| 31 | 3.11 | Sanitary fixtures |  | 5d | 2026-07-07 | 2026-07-13 | 10, 17, 28, 29, 30 |  |  |  |
| 32 | 3.12 | Ceiling painting 1st phase |  | 5d | 2026-05-26 | 2026-06-01 | 5, 24 |  |  |  |
| 33 | 3.13 | Wall painting 1st phase |  | 10d | 2026-06-02 | 2026-06-15 | 32 |  |  |  |
| 34 | 3.14 | Electrical works indoor |  | 15d | 2026-06-16 | 2026-07-06 | 33 |  |  |  |
| 35 | 3.15 | A/C Installation |  | 3d | 2026-07-21 | 2026-07-23 | 34FS+10d |  |  |  |
| 36 | 3.16 | Windows ιinstallation |  | 10d | 2026-07-08 | 2026-07-21 | 7FS+90d |  |  |  |
| 37 | 3.17 | Carpentry |  | 10d | 2026-07-22 | 2026-08-04 | 36 |  |  |  |
| 38 | 3.18 | Mezzanine, beams & stair installation |  | 12d | 2026-07-22 | 2026-08-06 | 36 |  |  |  |
| 39 | 3.19 | Kitchen |  | 3d | 2026-08-07 | 2026-08-11 | 38 |  |  |  |
| 40 | 3.20 | Ext.plaster 2: finishes |  | 15d | 2026-06-15 | 2026-07-03 | 2, 47, 52 |  |  |  |
| 41 | 3.21 | Roof tiling |  | 5d | 2026-07-06 | 2026-07-10 | 40 |  |  |  |
| 42 | 3.22 | Final interior & exterior painting |  | 15d | 2026-08-12 | 2026-09-01 | 37, 39 |  |  |  |
| 43 | 3.23 | Lighting fixtures & electrical devices |  | 10d | 2026-09-02 | 2026-09-15 | 42 |  |  |  |

Notes:
- 10: να τελειώσει στο σπίτι (και σιφώνια ντουσιέρες), ξενώνα / θα κατεβάσει τα σιφώνια;;
- 17: Ειδοποιήθηκε για έναρξη 5/3/2026 με τηλέφωνο και email
- 25: Στούντιο ΚΑΙ γωνιόκρανα στα μπάνια
- 26: γωνιόκρανα, λεπτομέρειες
- 29: Ειδοποιήθηκε για έναρξη 5/3/2026 με τηλέφωνο και email

| ID | WBS | Task | Duration | Start | Finish | Predecessors | Complete |
| --- | --- | --- | --- | --- | --- | --- | --- |
| 44 | 4 | **Outdoor tasks** | 188d | 2026-01-06 | 2026-09-29 |  | 33% |
| 45 | 4.1 | Landscape stone walls 1st phase | 145d | 2026-01-06 | 2026-07-30 |  | 52% |
| 46 | 4.2 | Rain gutters installation | 3d | 2026-01-19 | 2026-01-21 |  | 66% |
| 47 | 4.3 | Roof insulation & water proofing | 10d | 2026-01-22 | 2026-02-04 | 46 | 100% |
| 48 | 4.4 | Stone facades and insulation | 18d | 2026-04-23 | 2026-05-18 | 47 | 51% |
| 49 | 4.5 | Green roof house and guesthouse | 5d | 2026-06-16 | 2026-06-22 | 47, 48 |  |
| 50 | 4.6 | Eartworks 2nd stage | 10d | 2026-05-06 | 2026-05-19 | 45SS+7d |  |
| 51 | 4.7 | Concrete for pool cover | 5d | 2026-05-18 | 2026-05-22 | 50SS+8d |  |
| 52 | 4.8 | Concrete & sloping of exterior levels | 15d | 2026-05-25 | 2026-06-12 | 51 |  |
| 53 | 4.9 | Pool leveling | 11d | 2026-06-15 | 2026-06-29 | 52 |  |
| 54 | 4.10 | Electrical outdoor works | 10d | 2026-06-15 | 2026-06-26 | 52 |  |
| 55 | 4.11 | Plumbing outdoor works | 8d | 2026-06-15 | 2026-06-24 | 52 |  |
| 56 | 4.12 | Concrete floor outdoor installation | 15d | 2026-06-29 | 2026-07-17 | 29, 54, 55 |  |
| 57 | 4.13 | Landscaping | 15d | 2026-05-15 | 2026-06-04 |  |  |
| 58 | 4.14 | Pergola | 5d | 2026-07-08 | 2026-07-14 |  |  |
| 59 | 4.15 | Swimming pool electrical and plumbing works | 2d | 2026-07-20 | 2026-07-21 | 56 |  |
| 60 | 4.16 | Pool screed | 5d | 2026-09-02 | 2026-09-08 | 42, 59 |  |
| 61 | 4.17 | Earthworks 3rd stage | 10d | 2026-09-16 | 2026-09-29 | 43 |  |
